# My New House

Schedule from MS Project, 2015-10-05 to 2016-07-26.

## Calendars

- Standard: Mon-Fri 08:00-12:00, 13:00-17:00; Sat-Sun off. Exceptions (off unless hours are given): 2015-11-26 to 2016-11-24 (Thanksgiving, recurring), 2015-11-27 to 2016-11-25 (After Thanksgiving, recurring), 2015-12-25 to 2016-12-25 (Christmas, recurring), 2015-12-28 to 2016-01-01 (Week after Christmas).

## Schedule

| ID | Task | Type | Duration | Start | Finish | Predecessors | Total slack | Free slack |
| --- | --- | --- | --- | --- | --- | --- | --- | --- |
| 1 | Acquire land |  | 30d | 2015-10-05 | 2015-11-13 |  | 0d |  |
| 2 | Create architectural design |  | 20d | 2015-11-16 | 2015-12-15 | 1 | 0d |  |
| 3 | Acquire loan |  | 10d | 2015-12-16 | 2016-01-06 | 2 | 0d |  |
| 4 | Acquire permits |  | 38d | 2016-01-07 | 2016-02-29 | 3 | 0d |  |
| 5 | Excavate land |  | 12d | 2016-03-01 | 2016-03-16 | 4 | 0d |  |
| 6 | Pour foundation |  | 5d | 2016-03-17 | 2016-03-23 | 5 | 0d |  |
| 7 | Install house frame |  | 15d | 2016-03-24 | 2016-04-13 | 6 | 0d |  |
| 8 | Install cabling |  | 10d | 2016-04-14 | 2016-04-27 | 7 | 60d | 0d |
| 9 | Install plumbing |  | 14d | 2016-04-14 | 2016-05-03 | 8SS | 60d |  |
| 10 | Install HVAC |  | 8d | 2016-04-14 | 2016-04-25 | 7 | 0d |  |
| 11 | Install roofing |  | 5d | 2016-04-26 | 2016-05-02 | 10 | 0d |  |
| 12 | Installing siding |  | 15d | 2016-05-03 | 2016-05-23 | 11 | 0d |  |
| 13 | Install drywall |  | 15d | 2016-05-24 | 2016-06-13 | 12 | 0d |  |
| 14 | Install furnishings |  | 10d | 2016-06-14 | 2016-06-27 | 13 | 21d |  |
| 15 | Hire interior designer |  | 5d | 2016-04-14 | 2016-04-20 | 7 | 69d |  |
| 16 | Paint walls |  | 7d | 2016-06-14 | 2016-06-22 | 13 | 0d |  |
| 17 | Build out kitchen |  | 14d | 2016-06-23 | 2016-07-12 | 16 | 0d |  |
| 18 | Add furniture |  | 3d | 2016-07-13 | 2016-07-15 | 17 | 0d |  |
| 19 | Walkthroughs and final approvals |  | 5d | 2016-07-18 | 2016-07-22 | 18 | 0d |  |
| 20 | Pay final contractor fees |  | 2d | 2016-07-25 | 2016-07-26 | 19 | 0d |  |
| 21 | Move in | milestone | 0d | 2016-07-26 | 2016-07-26 | 20 | 0d |  |
